# Sample Building Project 01

Schedule from MS Project, 2018-09-23 to 2019-03-14.

## Calendars

- Sample Building: Mon-Thu 08:00-12:00, 13:00-17:00; Fri off; Sat-Sun 08:00-12:00, 13:00-17:00.

## Schedule

| ID | WBS | Task | Type | Duration | Start | Finish | Predecessors | Total slack | Free slack | Shamsi Start | Shamsi Finish |
| --- | --- | --- | --- | --- | --- | --- | --- | --- | --- | --- | --- |
| 1 | 1 | **پروژه ساختماني نمونه** |  | 149d | 2018-09-23 | 2019-03-14 |  | 0d |  | 1397/7/1 | 1397/12/23 |
| 2 | 1.1 | آغاز پروژه | milestone | 0d | 2018-09-23 | 2018-09-23 |  | 0d |  | 1397/7/1 | 1397/7/1 |
| 3 | 1.2 | **تجهيز کارگاه** |  | 135d | 2018-09-23 | 2019-02-26 |  | 0d |  | 1397/7/1 | 1397/12/7 |
| 4 | 1.2.1 | تجهيز کارگاه اوليه |  | 25d | 2018-09-23 | 2018-10-21 | 2 | 0d |  | 1397/7/1 | 1397/7/29 |
| 5 | 1.2.2 | تجهيز کارگاه در طول پروژه |  | 110d | 2018-10-22 | 2019-02-26 | 4 | 2d |  | 1397/7/30 | 1397/12/7 |
| 6 | 1.3 | **خاکبرداري** |  | 4d | 2018-10-22 | 2018-10-25 |  | 0d |  | 1397/7/30 | 1397/8/3 |
| 7 | 1.3.1 | گودبرداري با ماشين |  | 2d | 2018-10-22 | 2018-10-23 | 4 | 0d |  | 1397/7/30 | 1397/8/1 |
| 8 | 1.3.2 | خاکبرداري دستي و رگلاژ کف |  | 2d | 2018-10-24 | 2018-10-25 | 7 | 0d |  | 1397/8/2 | 1397/8/3 |
| 9 | 1.4 | **فونداسيون** |  | 16d | 2018-10-27 | 2018-11-13 |  | 0d |  | 1397/8/5 | 1397/8/22 |
| 10 | 1.4.1 | اجراي بتن مگر |  | 3d | 2018-10-27 | 2018-10-29 | 8 | 0d |  | 1397/8/5 | 1397/8/7 |
| 11 | 1.4.2 | آرماتور فونداسيون |  | 7d | 2018-10-30 | 2018-11-06 | 10 | 0d |  | 1397/8/8 | 1397/8/15 |
| 12 | 1.4.3 | قالب بندي فونداسيون |  | 5d | 2018-11-07 | 2018-11-12 | 11 | 0d |  | 1397/8/16 | 1397/8/21 |
| 13 | 1.4.4 | بتن ريزي فونداسيون |  | 1d | 2018-11-13 | 2018-11-13 | 12 | 0d |  | 1397/8/22 | 1397/8/22 |
| 14 | 1.5 | **اسکلت** |  | 49d | 2018-10-22 | 2018-12-17 |  | 0d |  | 1397/7/30 | 1397/9/26 |
| 15 | 1.5.1 | اجراي شابلون و گروت ريزي |  | 2d | 2018-11-14 | 2018-11-15 | 13 | 0d |  | 1397/8/23 | 1397/8/24 |
| 16 | 1.5.2 | اجراي بيس پليت ستونها |  | 3d | 2018-11-17 | 2018-11-19 | 15 | 0d |  | 1397/8/26 | 1397/8/28 |
| 17 | 1.5.3 | ساخت ستون |  | 10d | 2018-10-22 | 2018-11-01 | 4 | 3d | 0d | 1397/7/30 | 1397/8/10 |
| 18 | 1.5.4 | ساخت تير |  | 15d | 2018-11-03 | 2018-11-19 | 17 | 3d | 0d | 1397/8/12 | 1397/8/28 |
| 19 | 1.5.5 | ساخت بادبند و پله |  | 5d | 2018-11-20 | 2018-11-25 | 18 | 6d |  | 1397/8/29 | 1397/9/4 |
| 20 | 1.5.6 | نصب ستون |  | 3d | 2018-11-20 | 2018-11-22 | 17, 16 | 0d |  | 1397/8/29 | 1397/9/1 |
| 21 | 1.5.7 | نصب تيرهاي حمال |  | 8d | 2018-11-24 | 2018-12-02 | 18, 20 | 0d |  | 1397/9/3 | 1397/9/11 |
| 22 | 1.5.8 | نصب بادبند |  | 3d | 2018-12-03 | 2018-12-05 | 19, 21 | 0d |  | 1397/9/12 | 1397/9/14 |
| 23 | 1.5.9 | نصب تير پله |  | 2d | 2018-12-03 | 2018-12-04 | 19, 21 | 1d |  | 1397/9/12 | 1397/9/13 |
| 24 | 1.5.10 | اتصالات،جوشکاري و ضد زنگ |  | 10d | 2018-12-06 | 2018-12-17 | 20, 21, 22, 23 | 0d |  | 1397/9/15 | 1397/9/26 |

| ID | WBS | Task | Duration | Start | Finish | Predecessors | Total slack | Free slack | Shamsi Start | Shamsi Finish |
| --- | --- | --- | --- | --- | --- | --- | --- | --- | --- | --- |
| 25 | 1.6 | **سقف سازي** | 44d | 2018-11-14 | 2019-01-03 |  | 19d |  | 1397/8/23 | 1397/10/13 |
| 26 | 1.6.1 | ساخت تيرچه هاي فلزي | 10d | 2018-11-14 | 2018-11-25 | 13 | 19d |  | 1397/8/23 | 1397/9/4 |
| 27 | 1.6.2 | اجراي سقف همکف | 4d | 2018-12-18 | 2018-12-22 | 26, 24 | 0d |  | 1397/9/27 | 1397/10/1 |
| 28 | 1.6.3 | اجراي سقف اول | 4d | 2018-12-23 | 2018-12-26 | 27 | 0d |  | 1397/10/2 | 1397/10/5 |
| 29 | 1.6.4 | اجراي سقف دوم | 4d | 2018-12-27 | 2018-12-31 | 28 | 0d |  | 1397/10/6 | 1397/10/10 |
| 30 | 1.6.5 | اجراي کنسولها و پله | 3d | 2019-01-01 | 2019-01-03 | 29 | 20d | 3d | 1397/10/11 | 1397/10/13 |
| 31 | 1.7 | **سفت کاري** | 28d | 2018-12-18 | 2019-01-19 |  | 17d |  | 1397/9/27 | 1397/10/29 |
| 32 | 1.7.1 | خاکريزي پي و پشت ديوارها | 3d | 2018-12-18 | 2018-12-20 | 24 | 17d | 0d | 1397/9/27 | 1397/9/29 |
| 33 | 1.7.2 | اجراي ديوار چيني | 15d | 2018-12-22 | 2019-01-07 | 32 | 17d | 0d | 1397/10/1 | 1397/10/17 |
| 34 | 1.7.3 | ساخت و نصب نعل درگاه ها | 4d | 2019-01-08 | 2019-01-12 | 30, 33 | 17d | 0d | 1397/10/18 | 1397/10/22 |
| 35 | 1.7.4 | چهارچوب،فريم پنجره ها | 6d | 2019-01-13 | 2019-01-19 | 34 | 17d |  | 1397/10/23 | 1397/10/29 |
| 36 | 1.8 | **تاسيسات فاز اول** | 13d | 2019-01-01 | 2019-01-15 |  | 0d |  | 1397/10/11 | 1397/10/25 |
| 37 | 1.8.1 | اجراي لوله هاي فاضلاب و آب باران | 4d | 2019-01-01 | 2019-01-05 | 29 | 31d | 0d | 1397/10/11 | 1397/10/15 |
| 38 | 1.8.2 | اجراي لوله کشي سرد و گرم | 8d | 2019-01-06 | 2019-01-14 | 37 | 31d | 21d | 1397/10/16 | 1397/10/24 |
| 39 | 1.8.3 | اجراي کانالهاي هوا | 12d | 2019-01-01 | 2019-01-14 | 29 | 33d | 8d | 1397/10/11 | 1397/10/24 |
| 40 | 1.8.4 | اجراي لوله هاي برق | 8d | 2019-01-01 | 2019-01-09 | 29 | 0d |  | 1397/10/11 | 1397/10/19 |
| 41 | 1.8.5 | نصب ساپورتهاي تاسيساتي | 5d | 2019-01-10 | 2019-01-15 | 40 | 0d |  | 1397/10/20 | 1397/10/25 |
| 42 | 1.9 | **کف سازي** | 7d | 2019-01-16 | 2019-01-23 |  | 14d |  | 1397/10/26 | 1397/11/3 |
| 43 | 1.9.1 | اجراي پوکه سرويس ها | 4d | 2019-01-16 | 2019-01-20 | 41 | 17d | 0d | 1397/10/26 | 1397/10/30 |
| 44 | 1.9.2 | اجراي پوکه طبقات | 6d | 2019-01-16 | 2019-01-22 | 41 | 44d |  | 1397/10/26 | 1397/11/2 |
| 45 | 1.9.3 | شيب بندي و پوکه ريزي بام | 2d | 2019-01-16 | 2019-01-17 | 41 | 14d | 0d | 1397/10/26 | 1397/10/27 |
| 46 | 1.9.4 | عايقکاري سرويس ها | 3d | 2019-01-21 | 2019-01-23 | 43 | 17d | 4d | 1397/11/1 | 1397/11/3 |
| 47 | 1.9.5 | عايق کاري بام | 2d | 2019-01-19 | 2019-01-20 | 45 | 14d | 0d | 1397/10/29 | 1397/10/30 |
| 48 | 1.10 | **سقف کاذب** | 12d | 2019-01-16 | 2019-01-29 |  | 22d |  | 1397/10/26 | 1397/11/9 |
| 49 | 1.10.1 | زير سازي سقف کاذب | 8d | 2019-01-16 | 2019-01-24 | 41 | 22d | 0d | 1397/10/26 | 1397/11/4 |
| 50 | 1.10.2 | نصب صفحات رابيتس | 4d | 2019-01-26 | 2019-01-29 | 49 | 22d | 4d | 1397/11/6 | 1397/11/9 |

| ID | WBS | Task | Duration | Start | Finish | Predecessors | Total slack | Free slack | Shamsi Start | Shamsi Finish |
| --- | --- | --- | --- | --- | --- | --- | --- | --- | --- | --- |
| 51 | 1.11 | **نازک کاري** | 32d | 2019-01-16 | 2019-02-21 |  | 0d |  | 1397/10/26 | 1397/12/2 |
| 52 | 1.11.1 | گچ و خاک ديوارها | 16d | 2019-01-16 | 2019-02-03 | 41 | 0d |  | 1397/10/26 | 1397/11/14 |
| 53 | 1.11.2 | سيمانکاري آستر | 10d | 2019-01-16 | 2019-01-27 | 41 | 6d |  | 1397/10/26 | 1397/11/7 |
| 54 | 1.11.3 | سفيدکاري | 10d | 2019-02-04 | 2019-02-14 | 52, 53, 50 | 18d | 0d | 1397/11/15 | 1397/11/25 |
| 55 | 1.11.4 | رويه تخته ماله اي | 6d | 2019-02-16 | 2019-02-21 | 57, 54 | 18d |  | 1397/11/27 | 1397/12/2 |
| 56 | 1.11.5 | سنگ کف | 11d | 2019-01-16 | 2019-01-28 | 41 | 5d | 0d | 1397/10/26 | 1397/11/8 |
| 57 | 1.11.6 | سنگ قرنيز ديوارها | 4d | 2019-02-04 | 2019-02-07 | 52, 53, 56 | 0d |  | 1397/11/15 | 1397/11/18 |
| 58 | 1.11.7 | موزاييک | 3d | 2019-01-21 | 2019-01-23 | 47 | 25d | 0d | 1397/11/1 | 1397/11/3 |
| 59 | 1.11.8 | نصب سنگ پله | 3d | 2019-01-29 | 2019-01-31 | 56 | 6d | 0d | 1397/11/9 | 1397/11/11 |
| 60 | 1.11.9 | در و پنجره و نرده ها | 8d | 2019-02-09 | 2019-02-17 | 57, 56, 35 | 7d | 0d | 1397/11/20 | 1397/11/28 |
| 61 | 1.11.10 | درب و کمد چوبي | 8d | 2019-02-09 | 2019-02-17 | 57, 35, 56 | 0d |  | 1397/11/20 | 1397/11/28 |
| 62 | 1.12 | **نماسازي** | 26d | 2019-01-21 | 2019-02-19 |  | 8d |  | 1397/11/1 | 1397/11/30 |
| 63 | 1.12.1 | اجراي ازاره سنگي نما | 2d | 2019-01-21 | 2019-01-22 | 47 | 14d | 0d | 1397/11/1 | 1397/11/2 |
| 64 | 1.12.2 | اجراي سنگ نما | 16d | 2019-01-23 | 2019-02-10 | 63 | 14d | 6d | 1397/11/3 | 1397/11/21 |
| 65 | 1.12.3 | نصب شيشه ها | 2d | 2019-02-18 | 2019-02-19 | 60, 64 | 8d |  | 1397/11/29 | 1397/11/30 |
| 66 | 1.13 | **کاشي و سراميک** | 12d | 2019-01-29 | 2019-02-11 |  | 13d |  | 1397/11/9 | 1397/11/22 |
| 67 | 1.13.1 | کاشي کاري سرويسها | 6d | 2019-01-29 | 2019-02-04 | 56, 46 | 13d | 0d | 1397/11/9 | 1397/11/15 |
| 68 | 1.13.2 | نصب توالت هاي شرقي | 2d | 2019-02-05 | 2019-02-06 | 67 | 13d | 0d | 1397/11/16 | 1397/11/17 |
| 69 | 1.13.3 | نصب سراميک سرويسها | 4d | 2019-02-07 | 2019-02-11 | 68 | 13d | 0d | 1397/11/18 | 1397/11/22 |
| 70 | 1.14 | **تاسيسات فاز دوم** | 38d | 2019-01-16 | 2019-02-28 |  | 0d |  | 1397/10/26 | 1397/12/9 |
| 71 | 1.14.1 | ساخت و نصب دريچه ها | 4d | 2019-02-09 | 2019-02-12 | 38, 56, 57 | 10d | 0d | 1397/11/20 | 1397/11/23 |
| 72 | 1.14.2 | نصب دستگاه چيلر | 2d | 2019-01-24 | 2019-01-26 | 58, 39 | 25d | 15d | 1397/11/4 | 1397/11/6 |
| 73 | 1.14.3 | سيم کشي و کابل کشي | 8d | 2019-02-04 | 2019-02-12 | 52 | 9d |  | 1397/11/15 | 1397/11/23 |
| 74 | 1.14.4 | نصب کليد و پريز و ساير اقلام برقي | 4d | 2019-02-11 | 2019-02-14 | 84 | 6d |  | 1397/11/22 | 1397/11/25 |
| 75 | 1.14.5 | نصب چراغها | 1d | 2019-02-23 | 2019-02-23 | 86, 74 | 0d |  | 1397/12/4 | 1397/12/4 |
| 76 | 1.14.6 | ساخت و نصب تابلوهاي برق | 5d | 2019-02-24 | 2019-02-28 | 73, 75 | 0d |  | 1397/12/5 | 1397/12/9 |
| 77 | 1.14.7 | نصب سرويس هاي بهداشتي و شيرآلات | 2d | 2019-02-12 | 2019-02-13 | 69, 38 | 13d |  | 1397/11/23 | 1397/11/24 |
| 78 | 1.14.8 | نصب آسانسور | 30d | 2019-01-16 | 2019-02-19 | 41 | 8d |  | 1397/10/26 | 1397/11/30 |

| ID | WBS | Task | Type | Duration | Start | Finish | Predecessors | Total slack | Free slack | Shamsi Start | Shamsi Finish |
| --- | --- | --- | --- | --- | --- | --- | --- | --- | --- | --- | --- |
| 79 | 1.15 | **موتورخانه** |  | 28d | 2019-01-16 | 2019-02-17 |  | 10d |  | 1397/10/26 | 1397/11/28 |
| 80 | 1.15.1 | اجراي لوله کشي موتورخانه |  | 3d | 2019-01-16 | 2019-01-19 | 41 | 29d | 0d | 1397/10/26 | 1397/10/29 |
| 81 | 1.15.2 | نصب ديگها و مشعل پمپها |  | 2d | 2019-01-20 | 2019-01-21 | 80 | 29d | 19d | 1397/10/30 | 1397/11/1 |
| 82 | 1.15.3 | تست و راه اندازي و عايق کاري موتورخانه |  | 4d | 2019-02-13 | 2019-02-17 | 72, 71, 81 | 10d |  | 1397/11/24 | 1397/11/28 |
| 83 | 1.16 | **نقاشي** |  | 18d | 2019-02-02 | 2019-02-21 |  | 6d |  | 1397/11/13 | 1397/12/2 |
| 84 | 1.16.1 | اجراي کامل نقاشي سطوح گچي |  | 8d | 2019-02-02 | 2019-02-10 | 59 | 6d | 0d | 1397/11/13 | 1397/11/21 |
| 85 | 1.16.2 | اجراي کامل نقاشي سطوح فلزي |  | 3d | 2019-02-18 | 2019-02-20 | 60 | 7d |  | 1397/11/29 | 1397/12/1 |
| 86 | 1.16.3 | اجراي کامل نقاشي سطوح چوبي |  | 4d | 2019-02-18 | 2019-02-21 | 61 | 0d |  | 1397/11/29 | 1397/12/2 |
| 87 | 1.17 | **تميز کاري و تحويل و برچيدن کارگاه** |  | 12d | 2019-03-02 | 2019-03-14 |  | 0d |  | 1397/12/11 | 1397/12/23 |
| 88 | 1.17.1 | تميز کاري و تحويل و برچيدن کارگاه |  | 12d | 2019-03-02 | 2019-03-14 | 86, 82, 76, 65, 77, 85, 5, 78 | 0d |  | 1397/12/11 | 1397/12/23 |
| 89 | 1.18 | پايان پروژه | milestone | 0d | 2019-03-14 | 2019-03-14 | 88 | 0d |  | 1397/12/23 | 1397/12/23 |
